# A-91-00

Schedule from MS Project, 2026-05-21 to 2026-12-28, status date 2025-04-01.
Moorche 30 DVDs

## Calendars

- Standard: Mon-Sun 08:00-13:00, 14:00-17:00.

## Schedule

| ID | WBS | Task | Type | Duration | Start | Finish | Predecessors | Total slack | Free slack | Baseline cost | Text10 | Text11 | شروع | پایان | Text29 | Text30 | واحد | مقدار |
| --- | --- | --- | --- | --- | --- | --- | --- | --- | --- | --- | --- | --- | --- | --- | --- | --- | --- | --- |
| 1 | 1 | **EPC احداث خط 20 کیلوولت زارچ (استان یزد) به صورت** |  | 222d | 2026-05-21 | 2026-12-28 |  | 0d |  | 302,235,497,200 | 4/10/11 | 4/10/11 | 1405/2/31 | 1405/10/7 | 104/10/11 | 104/10/11 |  |  |
| 2 | 1.1 | **مایلستون** |  | 222d | 2026-05-21 | 2026-12-28 |  | 0d |  |  | 4/10/11 | 4/10/11 | 1405/2/31 | 1405/10/7 | 104/10/11 | 104/10/11 |  |  |
| 3 | 1.1.1 | شروع پروژه | milestone | 0d | 2026-05-21 | 2026-05-21 |  | 0d |  |  | 4/10/11 | 4/10/11 | 1405/2/31 | 1405/2/31 | 104/10/11 | 104/10/11 |  |  |
| 4 | 1.1.2 | پیش پرداخت | milestone | 0d | 2026-06-28 | 2026-06-28 | 3FS+39d | 0d |  |  | 4/10/11 | 4/10/11 | 1405/4/7 | 1405/4/7 | 104/10/11 | 104/10/11 |  |  |
| 5 | 1.1.4 | تحویل زمین | milestone | 0d | 2026-06-21 | 2026-06-21 | 3FS+32d | 7d |  |  | 4/10/11 | 4/10/11 | 1405/3/31 | 1405/3/31 | 104/10/11 | 104/10/11 |  |  |
| 6 | 1.1.5 | تایید نقشه های نهایی از کارفرما | milestone | 0d | 2026-08-29 | 2026-08-29 | 22 | 121d |  |  | 4/10/11 | 4/10/11 | 1405/6/7 | 1405/6/7 | 104/10/11 | 104/10/11 |  |  |
| 7 | 1.1.6 | تایید نقشه های نهایی از شرکت برق منطقه ای | milestone | 0d | 2026-08-29 | 2026-08-29 | 22 | 121d |  |  | 4/10/11 | 4/10/11 | 1405/6/7 | 1405/6/7 | 104/10/11 | 104/10/11 |  |  |
| 8 | 1.1.6 | تهیه و ارائه برنامه زمانبندی | milestone | 0d | 2026-07-11 | 2026-07-11 | 4FS+13d | 160d | 0d |  | 4/10/11 | 4/10/11 | 1405/4/20 | 1405/4/20 | 104/10/11 | 104/10/11 |  |  |
| 9 | 1.1.7 | QC PLAN تهیه و ارائه | milestone | 0d | 2026-07-21 | 2026-07-21 | 8FS+10d | 160d |  |  | 4/10/11 | 4/10/11 | 1405/4/30 | 1405/4/30 | 104/10/11 | 104/10/11 |  |  |
| 10 | 1.1.8 | خط و پست رستاق به کارفرما (AS BUILT) تحویل نقشه های | milestone | 0d | 2026-12-27 | 2026-12-27 | 126 | 1d |  |  | 4/10/11 | 4/10/11 | 1405/10/6 | 1405/10/6 | 104/10/11 | 104/10/11 |  |  |
| 11 | 1.1.9 | خط و پست رستاق به شرکت برق منطقه ای (AS BUILT) تحویل نقشه های | milestone | 0d | 2026-12-27 | 2026-12-27 | 126 | 1d |  |  | 4/10/11 | 4/10/11 | 1405/10/6 | 1405/10/6 | 104/10/11 | 104/10/11 |  |  |
| 12 | 1.1.10 | پایان پروژه | milestone | 0d | 2026-12-28 | 2026-12-28 | 127, 98, 97, 9, 10, 11, 6, 7 | 0d |  |  | 4/10/11 | 4/10/11 | 1405/10/7 | 1405/10/7 | 104/10/11 | 104/10/11 |  |  |
| 13 | 1.2 | **مهندسی** |  | 62d | 2026-06-29 | 2026-08-29 |  | 0d |  | 5,380,000,000 | 4/10/11 | 4/10/11 | 1405/4/8 | 1405/6/7 | 104/10/11 | 104/10/11 |  |  |
| 14 | 1.2.1 | مسیر یابی، نقشه برداری و تهیه پلان و پروفیل طولی |  | 7d | 2026-06-29 | 2026-07-05 | 5, 4 | 0d |  | 350,000,000 | 4/10/11 | 4/10/11 | 1405/4/8 | 1405/4/14 | 104/10/11 | 104/10/11 | کیلومتر | 10 |
| 15 | 1.2.2 | تعیین نوع سیم،برج، مقره و یراق آلات انجام محاسبات مکانیکی تعیین پارامتر سرد و گرم تهیه جدول فلش و کشش و انجام محاسبات بارگذاری در قالب گزارش و تهیه مشخصات فنی اجرا و ارائه نقشه های تیپ فونداسیون برج، سیستم زمین و تجهیزات شامل تیربتنی یابرج فلزی، سیم وسایر |  | 10d | 2026-07-06 | 2026-07-15 | 14 | 0d |  | 1,500,000,000 | 4/10/11 | 4/10/11 | 1405/4/15 | 1405/4/24 | 104/10/11 | 104/10/11 | پروژه |  |
| 16 | 1.2.5 | برج گذاری بروی پروفیل |  | 7d | 2026-07-16 | 2026-07-22 | 15 | 121d | 0d | 200,000,000 | 4/10/11 | 4/10/11 | 1405/4/25 | 1405/4/31 | 104/10/11 | 104/10/11 | کیلومتر | 20 |
| 17 | 1.2.6 | ارائه جدول سیم کشی |  | 8d | 2026-07-23 | 2026-07-30 | 16 | 121d | 0d | 180,000,000 | 4/10/11 | 4/10/11 | 1405/5/1 | 1405/5/8 | 104/10/11 | 104/10/11 | کیلومتر | 20 |
| 18 | 1.2.7 | نظارت بر آزمایشات مورد لزوم ساخت قطعات در کارخانه سازنده |  | 12d | 2026-07-31 | 2026-08-11 | 17 | 121d | 0d | 600,000,000 | 4/10/11 | 4/10/11 | 1405/5/9 | 1405/5/20 | 104/10/11 | 104/10/11 | نفر-روز | 20 |
| 19 | 1.2.8 | پست رستاق kv تهیه مشخصات فنی سوئیچگیر 20 |  | 7d | 2026-07-16 | 2026-07-22 | 15 | 121d | 0d | 300,000,000 | 4/10/11 | 4/10/11 | 1405/4/25 | 1405/4/31 | 104/10/11 | 104/10/11 | AS REQ |  |
| 20 | 1.2.9 | تهیه نقشه های توسعه سوئیچگیر پست رستاق |  | 7d | 2026-07-23 | 2026-07-29 | 19 | 121d | 0d | 350,000,000 | 4/10/11 | 4/10/11 | 1405/5/1 | 1405/5/7 | 104/10/11 | 104/10/11 | AS REQ |  |
| 21 | 1.2.10 | تهیه مدارک و نقشه های اصلاحات بخش توسعه پست شامل سیستم های کنترل،حفاظت،لاجیک،اندازه گیری |  | 16d | 2026-08-07 | 2026-08-22 | 20FS+8d | 121d | 0d | 450,000,000 | 4/10/11 | 4/10/11 | 1405/5/16 | 1405/5/31 | 104/10/11 | 104/10/11 | AS REQ |  |
| 22 | 1.2.11 | تهیه نقشه های نهایی با اخذ تایید از شرکت برق منطقه ای |  | 7d | 2026-08-23 | 2026-08-29 | 21, 14, 15, 16, 17, 23, 24, 25, 26 | 121d | 0d | 400,000,000 | 4/10/11 | 4/10/11 | 1405/6/1 | 1405/6/7 | 104/10/11 | 104/10/11 | AS REQ |  |
| 23 | 1.2.12 | تهیه مدارک مهندسی اتصال دو فیدر (سوئیچگیر ) 20 نیروگاه خورشیدی به خطوط هوایی |  | 14d | 2026-07-16 | 2026-07-29 | 15 | 121d | 0d | 500,000,000 | 4/10/11 | 4/10/11 | 1405/4/25 | 1405/5/7 | 104/10/11 | 104/10/11 | AS REQ |  |
| 24 | 1.2.13 | تهیه مدارک مهندسی سیستم مخابراتی نیروگاه خورشیدی |  | 14d | 2026-07-30 | 2026-08-12 | 23 | 121d | 0d | 350,000,000 | 4/10/11 | 4/10/11 | 1405/5/8 | 1405/5/21 | 104/10/11 | 104/10/11 | AS REQ |  |
| 25 | 1.2.14 | طراحی و مهندسی تجهیزات سیستم در محل پست رستاق |  | 10d | 2026-08-13 | 2026-08-22 | 24 | 121d | 0d | 50,000,000 | 4/10/11 | 4/10/11 | 1405/5/22 | 1405/5/31 | 104/10/11 | 104/10/11 | AS REQ |  |
| 26 | 1.2.15 | سایر مدارک مهندسی |  | 20d | 2026-08-03 | 2026-08-22 | 15, 17, 18SS+3d | 121d | 0d | 150,000,000 | 4/10/11 | 4/10/11 | 1405/5/12 | 1405/5/31 | 104/10/11 | 104/10/11 | AS REQ |  |

| ID | WBS | Task | Duration | Start | Finish | Predecessors | Total slack | Free slack | Baseline cost | Text10 | Text11 | شروع | پایان | Text29 | Text30 | واحد | مقدار |
| --- | --- | --- | --- | --- | --- | --- | --- | --- | --- | --- | --- | --- | --- | --- | --- | --- | --- |
| 27 | 1.3 | **تامین تجهیزات** | 105d | 2026-07-16 | 2026-10-28 |  | 0d |  | 252,501,497,200 | 4/10/11 | 4/10/11 | 1405/4/25 | 1405/8/6 | 104/10/11 | 104/10/11 |  |  |
| 28 | 1.3.1 | **تیر بتنی (به صورت کامل)** | 65d | 2026-07-16 | 2026-09-18 |  | 0d |  | 41,436,720,000 | 4/10/11 | 4/10/11 | 1405/4/25 | 1405/6/27 | 104/10/11 | 104/10/11 | عدد | 390 |
| 29 | 1.3.1.1 | سفارش گذاری | 10d | 2026-07-16 | 2026-07-25 | 15 | 0d |  |  | 4/10/11 | 4/10/11 | 1405/4/25 | 1405/5/3 | 104/10/11 | 104/10/11 |  |  |
| 30 | 1.3.1.2 | ساخت و بازرسی | 50d | 2026-07-26 | 2026-09-13 | 29 | 0d |  |  | 4/10/11 | 4/10/11 | 1405/5/4 | 1405/6/22 | 104/10/11 | 104/10/11 |  |  |
| 31 | 1.3.1.3 | حمل و تحویل به سایت | 45d | 2026-08-05 | 2026-09-18 | 30FS-40d | 0d |  |  | 4/10/11 | 4/10/11 | 1405/5/14 | 1405/6/27 | 104/10/11 | 104/10/11 |  |  |
| 32 | 1.3.2 | **مقره زنجیره آویزی یا اتکایی** | 70d | 2026-08-15 | 2026-10-23 |  | 5d |  | 13,719,040,000 | 4/10/11 | 4/10/11 | 1405/5/24 | 1405/8/1 | 104/10/11 | 104/10/11 | عدد | 2300 |
| 33 | 1.3.2.1 | سفارش گذاری | 10d | 2026-08-15 | 2026-08-24 | 29FS+20d | 5d | 0d |  | 4/10/11 | 4/10/11 | 1405/5/24 | 1405/6/2 | 104/10/11 | 104/10/11 |  |  |
| 34 | 1.3.2.2 | ساخت و بازرسی | 35d | 2026-08-25 | 2026-09-28 | 33 | 5d | 0d |  | 4/10/11 | 4/10/11 | 1405/6/3 | 1405/7/6 | 104/10/11 | 104/10/11 |  |  |
| 35 | 1.3.2.3 | حمل و تحویل به سایت | 25d | 2026-09-29 | 2026-10-23 | 34 | 5d |  |  | 4/10/11 | 4/10/11 | 1405/7/7 | 1405/8/1 | 104/10/11 | 104/10/11 |  |  |
| 36 | 1.3.3 | **(OPGW) سیم محافظ** | 90d | 2026-07-16 | 2026-10-13 |  | 0d |  | 14,142,168,000 | 4/10/11 | 4/10/11 | 1405/4/25 | 1405/7/21 | 104/10/11 | 104/10/11 | کیلومتر | 10 |
| 37 | 1.3.3.1 | سفارش گذاری | 10d | 2026-07-16 | 2026-07-25 | 15 | 0d |  |  | 4/10/11 | 4/10/11 | 1405/4/25 | 1405/5/3 | 104/10/11 | 104/10/11 |  |  |
| 38 | 1.3.3.2 | ساخت و بازرسی | 55d | 2026-07-26 | 2026-09-18 | 37 | 0d |  |  | 4/10/11 | 4/10/11 | 1405/5/4 | 1405/6/27 | 104/10/11 | 104/10/11 |  |  |
| 39 | 1.3.3.3 | حمل و تحویل به سایت | 35d | 2026-09-09 | 2026-10-13 | 38SS+45d | 0d |  |  | 4/10/11 | 4/10/11 | 1405/6/18 | 1405/7/21 | 104/10/11 | 104/10/11 |  |  |
| 40 | 1.3.4 | **Hyena سیم هادی** | 100d | 2026-07-16 | 2026-10-23 |  | 0d |  | 99,164,800,000 | 4/10/11 | 4/10/11 | 1405/4/25 | 1405/8/1 | 104/10/11 | 104/10/11 | کیلوگرم | 56000 |
| 41 | 1.3.4.1 | سفارش گذاری | 10d | 2026-07-16 | 2026-07-25 | 15 | 0d |  |  | 4/10/11 | 4/10/11 | 1405/4/25 | 1405/5/3 | 104/10/11 | 104/10/11 |  |  |
| 42 | 1.3.4.2 | ساخت و بازرسی | 55d | 2026-07-26 | 2026-09-18 | 41 | 0d |  |  | 4/10/11 | 4/10/11 | 1405/5/4 | 1405/6/27 | 104/10/11 | 104/10/11 |  |  |
| 43 | 1.3.4.3 | حمل و تحویل به سایت | 35d | 2026-09-19 | 2026-10-23 | 42 | 0d |  |  | 4/10/11 | 4/10/11 | 1405/6/28 | 1405/8/1 | 104/10/11 | 104/10/11 |  |  |
| 44 | 1.3.5 | **تامین تابلو های 20 کیلوولت** | 75d | 2026-07-26 | 2026-10-08 |  | 51d |  | 33,000,000,000 | 4/10/11 | 4/10/11 | 1405/5/4 | 1405/7/16 | 104/10/11 | 104/10/11 | دستگاه |  |
| 45 | 1.3.5.1 | سفارش گذاری | 10d | 2026-07-26 | 2026-08-04 | 29 | 51d | 0d |  | 4/10/11 | 4/10/11 | 1405/5/4 | 1405/5/13 | 104/10/11 | 104/10/11 |  |  |
| 46 | 1.3.5.2 | ساخت و بازرسی | 40d | 2026-08-05 | 2026-09-13 | 45 | 51d | 0d |  | 4/10/11 | 4/10/11 | 1405/5/14 | 1405/6/22 | 104/10/11 | 104/10/11 |  |  |
| 47 | 1.3.5.3 | حمل و تحویل به سایت | 25d | 2026-09-14 | 2026-10-08 | 46 | 51d |  |  | 4/10/11 | 4/10/11 | 1405/6/23 | 1405/7/16 | 104/10/11 | 104/10/11 |  |  |
| 48 | 1.3.6 | **تامین کابل آلومینیومی** | 75d | 2026-07-26 | 2026-10-08 |  | 51d |  | 7,670,000,000 | 4/10/11 | 4/10/11 | 1405/5/4 | 1405/7/16 | 104/10/11 | 104/10/11 | AS REQ |  |
| 49 | 1.3.6.1 | سفارش گذاری | 10d | 2026-07-26 | 2026-08-04 | 45SS | 51d | 0d |  | 4/10/11 | 4/10/11 | 1405/5/4 | 1405/5/13 | 104/10/11 | 104/10/11 |  |  |
| 50 | 1.3.6.2 | ساخت و بازرسی | 40d | 2026-08-05 | 2026-09-13 | 49 | 51d | 0d |  | 4/10/11 | 4/10/11 | 1405/5/14 | 1405/6/22 | 104/10/11 | 104/10/11 |  |  |
| 51 | 1.3.6.3 | حمل و تحویل به سایت | 25d | 2026-09-14 | 2026-10-08 | 50 | 51d |  |  | 4/10/11 | 4/10/11 | 1405/6/23 | 1405/7/16 | 104/10/11 | 104/10/11 |  |  |

| ID | WBS | Task | Duration | Start | Finish | Predecessors | Total slack | Baseline cost | واحد | Text10 | Text11 | شروع | پایان | Text29 | Text30 | مقدار |
| --- | --- | --- | --- | --- | --- | --- | --- | --- | --- | --- | --- | --- | --- | --- | --- | --- |
| 52 | 1.3.7 | **یراق آلات و سایر اقلام** | 75d | 2026-08-15 | 2026-10-28 |  | 40d | 43,368,769,200 | پروژه | 4/10/11 | 4/10/11 | 1405/5/24 | 1405/8/6 | 104/10/11 | 104/10/11 |  |
| 53 | 1.3.7.1 | مقره زنجیره کششی | 35d | 2026-08-15 | 2026-09-18 | 29FS+20d | 40d | 2,833,280,000 | 400 | 4/10/11 | 4/10/11 | 1405/5/24 | 1405/6/27 | 104/10/11 | 104/10/11 | عدد |
| 54 | 1.3.7.2 | کراس آرم 1/5 متری با نبشی 10*100*100 گالوانیزه گرم | 35d | 2026-09-21 | 2026-10-25 | 30FS+7d | 3d | 5,331,040,000 | 650 | 4/10/11 | 4/10/11 | 1405/6/30 | 1405/8/3 | 104/10/11 | 104/10/11 | عدد |
| 55 | 1.3.7.3 | کراس آرم 1/5 متری با نبشی 12*120*120 گالوانیزه گرم | 35d | 2026-09-21 | 2026-10-25 | 30FS+7d | 3d | 657,060,000 | 75 | 4/10/11 | 4/10/11 | 1405/6/30 | 1405/8/3 | 104/10/11 | 104/10/11 | عدد |
| 56 | 1.3.7.4 | کراس آرم 2 متری با نبشی 10*120*120گالوانیزه گرم | 35d | 2026-09-21 | 2026-10-25 | 30FS+7d | 3d | 3,574,220,000 | 325 | 4/10/11 | 4/10/11 | 1405/6/30 | 1405/8/3 | 104/10/11 | 104/10/11 | عدد |
| 57 | 1.3.7.5 | کراس آرم 2 متری با نبشی 12*120*120 گالوانیزه گرم | 35d | 2026-09-21 | 2026-10-25 | 30FS+7d | 3d | 495,824,000 | 40 | 4/10/11 | 4/10/11 | 1405/6/30 | 1405/8/3 | 104/10/11 | 104/10/11 | عدد |
| 58 | 1.3.7.6 | کراس آرم 3 متری با نبشی 12*120*120 گالوانیزه گرم | 35d | 2026-09-21 | 2026-10-25 | 30FS+7d | 3d | 1,280,664,000 | 90 | 4/10/11 | 4/10/11 | 1405/6/30 | 1405/8/3 | 104/10/11 | 104/10/11 | عدد |
| 59 | 1.3.7.7 | انواع آهن آلات گالوانیزه گرم | 30d | 2026-09-21 | 2026-10-20 | 30FS+7d | 8d | 466,000,000 | 1,000 | 4/10/11 | 4/10/11 | 1405/6/30 | 1405/7/28 | 104/10/11 | 104/10/11 | کیلوگرم |
| 60 | 1.3.7.8 | تسمه حایل کراس آرم 5*50*700 میلی متر گالوانیزه گرم | 30d | 2026-09-21 | 2026-10-20 | 30FS+7d | 8d | 2,604,940,000 | 2,150 | 4/10/11 | 4/10/11 | 1405/6/30 | 1405/7/28 | 104/10/11 | 104/10/11 | عدد |
| 61 | 1.3.7.9 | سکو کات اوت و برقگیر با دو عدد ناودانی نمره 8 گالوانیزه گرم به طول 4/2 متر | 30d | 2026-09-21 | 2026-10-20 | 30FS+7d | 8d | 106,248,000 |  | 4/10/11 | 4/10/11 | 1405/6/30 | 1405/7/28 | 104/10/11 | 104/10/11 | عدد |
| 62 | 1.3.7.10 | سکو مخصوص سر کابل هوایی گالوانیزه گرم | 30d | 2026-09-21 | 2026-10-20 | 30FS+7d | 8d | 82,016,000 |  | 4/10/11 | 4/10/11 | 1405/6/30 | 1405/7/28 | 104/10/11 | 104/10/11 | عدد |
| 63 | 1.3.7.11 | مهار به صورت کامل | 30d | 2026-09-21 | 2026-10-20 | 30FS+7d | 8d | 1,207,872,000 | 12 | 4/10/11 | 4/10/11 | 1405/6/30 | 1405/7/28 | 104/10/11 | 104/10/11 | عدد |
| 64 | 1.3.7.12 | کات اوت سه فاز قطع هم زمان جهت رده ولتاژ 20 کیلو ولت | 35d | 2026-09-21 | 2026-10-25 | 30FS+7d | 3d | 2,477,256,000 |  | 4/10/11 | 4/10/11 | 1405/6/30 | 1405/8/3 | 104/10/11 | 104/10/11 | سری |
| 65 | 1.3.7.13 | تیغه جداکننده 630 آمپری پلیمری جهت رده ولتاژی 20 کیلو ولت | 30d | 2026-09-21 | 2026-10-20 | 30FS+7d | 8d | 849,984,000 |  | 4/10/11 | 4/10/11 | 1405/6/30 | 1405/7/28 | 104/10/11 | 104/10/11 | عدد |
| 66 | 1.3.7.14 | برقگیر فشار متوسط هوایی با جریان تخلیه نامی 5 یا 10 کیلو آمپر جهت رده ولتاژی 20 کیلو ولت | 35d | 2026-09-21 | 2026-10-25 | 30FS+7d | 3d | 282,955,200 |  | 4/10/11 | 4/10/11 | 1405/6/30 | 1405/8/3 | 104/10/11 | 104/10/11 | عدد |
| 67 | 1.3.7.15 | دیسکانکتور برقگیر فشار متوسط | 35d | 2026-09-21 | 2026-10-25 | 30FS+7d | 3d | 22,368,000 |  | 4/10/11 | 4/10/11 | 1405/6/30 | 1405/8/3 | 104/10/11 | 104/10/11 | عدد |
| 68 | 1.3.7.16 | برقگیر فشار متوسط هوایی با جریان تخلیه نامی 5 یا 10 کیلو آمپر جهت رده ولتاژی 20 کیلو ولت | 35d | 2026-09-21 | 2026-10-25 | 30FS+7d | 3d | 285,192,000 |  | 4/10/11 | 4/10/11 | 1405/6/30 | 1405/8/3 | 104/10/11 | 104/10/11 | عدد |
| 69 | 1.3.7.17 | میله جلو برنده مقره به طول 45 سانتی متر و حداقل نیروی کشش 12000 کیلوگرم | 35d | 2026-09-21 | 2026-10-25 | 30FS+7d | 3d | 708,320,000 | 400 | 4/10/11 | 4/10/11 | 1405/6/30 | 1405/8/3 | 104/10/11 | 104/10/11 | عدد |
| 70 | 1.3.7.18 | آی بال | 35d | 2026-09-21 | 2026-10-25 | 30FS+7d | 3d | 223,680,000 | 400 | 4/10/11 | 4/10/11 | 1405/6/30 | 1405/8/3 | 104/10/11 | 104/10/11 | عدد |
| 71 | 1.3.7.19 | آی ساکت | 30d | 2026-09-21 | 2026-10-20 | 30FS+7d | 8d | 223,680,000 | 400 | 4/10/11 | 4/10/11 | 1405/6/30 | 1405/7/28 | 104/10/11 | 104/10/11 | عدد |
| 72 | 1.3.7.20 | شگل | 30d | 2026-09-21 | 2026-10-20 | 30FS+7d | 8d | 559,200,000 | 400 | 4/10/11 | 4/10/11 | 1405/6/30 | 1405/7/28 | 104/10/11 | 104/10/11 | عدد |
| 73 | 1.3.7.21 | مهره چشمی | 30d | 2026-09-21 | 2026-10-20 | 30FS+7d | 8d | 559,200,000 | 400 | 4/10/11 | 4/10/11 | 1405/6/30 | 1405/7/28 | 104/10/11 | 104/10/11 | عدد |
| 74 | 1.3.7.22 | پیچ و مهره یک سر رزوه | 30d | 2026-09-21 | 2026-10-20 | 30FS+7d | 8d | 100,560,000 | 120 | 4/10/11 | 4/10/11 | 1405/6/30 | 1405/7/28 | 104/10/11 | 104/10/11 | کیلوگرم |
| 75 | 1.3.7.23 | پیچ و مهره دو سر رزوه | 30d | 2026-09-21 | 2026-10-20 | 30FS+7d | 8d | 1,046,250,000 | 1,125 | 4/10/11 | 4/10/11 | 1405/6/30 | 1405/7/28 | 104/10/11 | 104/10/11 | کیلوگرم |
| 76 | 1.3.7.24 | پایه مقره راس تیری سرامیکی | 30d | 2026-09-21 | 2026-10-20 | 30FS+7d | 8d | 968,500,000 | 325 | 4/10/11 | 4/10/11 | 1405/6/30 | 1405/7/28 | 104/10/11 | 104/10/11 | عدد |
| 77 | 1.3.7.25 | کلمپ انتهایی سیم بدون روکش (سیم گیر) پنج پیچ | 30d | 2026-09-21 | 2026-10-20 | 30FS+7d | 8d | 3,800,000,000 | 400 | 4/10/11 | 4/10/11 | 1405/6/30 | 1405/7/28 | 104/10/11 | 104/10/11 | عدد |
| 78 | 1.3.7.26 | غلاف تعمیری | 30d | 2026-09-21 | 2026-10-20 | 30FS+7d | 8d | 33,500,000 | 20 | 4/10/11 | 4/10/11 | 1405/6/30 | 1405/7/28 | 104/10/11 | 104/10/11 | عدد |
| 79 | 1.3.7.27 | مفصل میانی هادی | 30d | 2026-09-21 | 2026-10-20 | 30FS+7d | 8d | 33,500,000 | 20 | 4/10/11 | 4/10/11 | 1405/6/30 | 1405/7/28 | 104/10/11 | 104/10/11 | عدد |
| 80 | 1.3.7.28 | joint box | 30d | 2026-09-21 | 2026-10-20 | 30FS+7d | 8d | 559,200,000 |  | 4/10/11 | 4/10/11 | 1405/6/30 | 1405/7/28 | 104/10/11 | 104/10/11 | عدد |
| 81 | 1.3.7.29 | مفصل میانی | 30d | 2026-09-21 | 2026-10-20 | 30FS+7d | 8d | 58,500,000 |  | 4/10/11 | 4/10/11 | 1405/6/30 | 1405/7/28 | 104/10/11 | 104/10/11 | AS REQ |
| 82 | 1.3.7.30 | میله فولادی با روکش مسی به قطر 20 میلی متر و بطول 2 متر | 30d | 2026-09-21 | 2026-10-20 | 30FS+7d | 8d | 247,800,000 | 70 | 4/10/11 | 4/10/11 | 1405/6/30 | 1405/7/28 | 104/10/11 | 104/10/11 | عدد |
| 83 | 1.3.7.31 | سیم زمین | 30d | 2026-09-21 | 2026-10-20 | 30FS+7d | 8d | 746,000,000 | 400 | 4/10/11 | 4/10/11 | 1405/6/30 | 1405/7/28 | 104/10/11 | 104/10/11 | کیلوگرم |
| 84 | 1.3.7.32 | کلمپ اتصال سیم زمین به سیم گارد | 30d | 2026-09-21 | 2026-10-20 | 30FS+7d | 8d | 208,600,000 | 70 | 4/10/11 | 4/10/11 | 1405/6/30 | 1405/7/28 | 104/10/11 | 104/10/11 | عدد |
| 85 | 1.3.7.33 | کلمپ اتصال سیم زمین به میله زمین | 30d | 2026-09-21 | 2026-10-20 | 30FS+7d | 8d | 78,260,000 | 70 | 4/10/11 | 4/10/11 | 1405/6/30 | 1405/7/28 | 104/10/11 | 104/10/11 | عدد |
| 86 | 1.3.7.34 | کلمپ اتصال سیم زمین به سیم زمین | 30d | 2026-09-21 | 2026-10-20 | 30FS+7d | 8d | 22,350,000 |  | 4/10/11 | 4/10/11 | 1405/6/30 | 1405/7/28 | 104/10/11 | 104/10/11 | AS REQ |
| 87 | 1.3.7.35 | بست کمربندی دور پایه بتنی | 30d | 2026-09-21 | 2026-10-20 | 30FS+7d | 8d | 652,750,000 | 350 | 4/10/11 | 4/10/11 | 1405/6/30 | 1405/7/28 | 104/10/11 | 104/10/11 | عدد |
| 88 | 1.3.7.36 | ...تامین تجهیزات کنترل و اندازه گیری برای نصب در تابلو های کنترل و اصلاح میمک و | 30d | 2026-09-21 | 2026-10-20 | 30FS+7d | 8d | 1,178,000,000 |  | 4/10/11 | 4/10/11 | 1405/6/30 | 1405/7/28 | 104/10/11 | 104/10/11 | AS REQ |
| 89 | 1.3.7.37 | از محل تابلوهای موجود پست رستاق kv تامین تجهیزات تغذیه داخلی تابلو های 20 | 30d | 2026-09-29 | 2026-10-28 | 30FS+15d | 31d | 1,178,000,000 |  | 4/10/11 | 4/10/11 | 1405/7/7 | 1405/8/6 | 104/10/11 | 104/10/11 | AS REQ |
| 90 | 1.3.7.38 | تامین کابل های کنترل و قدرت با متعلقات مربوطه | 30d | 2026-09-29 | 2026-10-28 | 30FS+15d | 31d | 2,350,000,000 |  | 4/10/11 | 4/10/11 | 1405/7/7 | 1405/8/6 | 104/10/11 | 104/10/11 | AS REQ |
| 91 | 1.3.7.39 | تامین تجهیزات اندازه گیری انرژی بر اساس تایید شرکت برق منطقه ای | 30d | 2026-09-29 | 2026-10-28 | 30FS+15d | 48d | 1,416,000,000 |  | 4/10/11 | 4/10/11 | 1405/7/7 | 1405/8/6 | 104/10/11 | 104/10/11 | AS REQ |
| 92 | 1.3.7.40 | تامین متعلقات جانبی تجهیزات پست شامل ( سینی کابل ، سیم ارت ...) | 30d | 2026-09-29 | 2026-10-28 | 30FS+15d | 48d | 1,640,000,000 |  | 4/10/11 | 4/10/11 | 1405/7/7 | 1405/8/6 | 104/10/11 | 104/10/11 | AS REQ |
| 93 | 1.3.7.41 | تامین تجهیزات سیستم مخابراتی (شامل فیبر نوری و متعلقات جانبی جهت انتقال اطلاعات) در دو سمت پست رستاق و نیروگاه خورشیدی | 30d | 2026-09-29 | 2026-10-28 | 30FS+15d | 48d | 1,640,000,000 |  | 4/10/11 | 4/10/11 | 1405/7/7 | 1405/8/6 | 104/10/11 | 104/10/11 | AS REQ |
| 94 | 1.3.7.42 | سایر اقلام مورد نیاز | 30d | 2026-09-29 | 2026-10-28 | 30FS+15d | 5d | 580,000,000 |  | 4/10/11 | 4/10/11 | 1405/7/7 | 1405/8/6 | 104/10/11 | 104/10/11 | AS REQ |

| ID | WBS | Task | Duration | Start | Finish | Predecessors | Total slack | Free slack | Baseline cost | Text10 | Text11 | شروع | پایان | Text29 | Text30 | واحد | مقدار |
| --- | --- | --- | --- | --- | --- | --- | --- | --- | --- | --- | --- | --- | --- | --- | --- | --- | --- |
| 95 | 1.4 | **عملیات اجرایی و تجهیز کارگاه** | 183d | 2026-06-29 | 2026-12-28 |  | 0d |  | 44,354,000,000 | 4/10/11 | 4/10/11 | 1405/4/8 | 1405/10/7 | 104/10/11 | 104/10/11 |  |  |
| 96 | 1.4.1 | **تجهیز و برچیدن کارگاه** | 179d | 2026-06-29 | 2026-12-24 |  | 4d |  | 8,168,000,000 | 4/10/11 | 4/10/11 | 1405/4/8 | 1405/10/3 | 104/10/11 | 104/10/11 |  |  |
| 97 | 1.4.1.1 | کارفرما | 179d | 2026-06-29 | 2026-12-24 | 4 | 4d |  | 3,668,000,000 | 4/10/11 | 4/10/11 | 1405/4/8 | 1405/10/3 | 104/10/11 | 104/10/11 | پروژه |  |
| 98 | 1.4.1.2 | پیمانکار | 179d | 2026-06-29 | 2026-12-24 | 4 | 4d |  | 4,500,000,000 | 4/10/11 | 4/10/11 | 1405/4/8 | 1405/10/3 | 104/10/11 | 104/10/11 | پروژه |  |
| 99 | 1.4.2 | **عملیات اجرایی** | 172d | 2026-07-10 | 2026-12-28 |  | 0d |  | 36,186,000,000 | 4/10/11 | 4/10/11 | 1405/4/19 | 1405/10/7 | 104/10/11 | 104/10/11 |  |  |
| 100 | 1.4.2.1 | احداث جاده دسترسی در زمین های معمولی و دشت | 13d | 2026-07-10 | 2026-07-22 | 14FS+4d | 0d |  | 590,000,000 | 4/10/11 | 4/10/11 | 1405/4/19 | 1405/4/31 | 104/10/11 | 104/10/11 | 10 | کیلومتر مسیر خط |
| 101 | 1.4.2.2 | کنترل نقشه برداری | 6d | 2026-07-10 | 2026-07-15 | 100SS | 0d |  | 196,000,000 | 4/10/11 | 4/10/11 | 1405/4/19 | 1405/4/24 | 104/10/11 | 104/10/11 | 10 | کیلومتر مسیر خط |
| 102 | 1.4.2.3 | پیاده کردن محل تیرها | 9d | 2026-07-10 | 2026-07-18 | 101SS | 0d |  | 760,500,000 | 4/10/11 | 4/10/11 | 1405/4/19 | 1405/4/27 | 104/10/11 | 104/10/11 | 390 | تیر |
| 103 | 1.4.2.4 | خاکبرداری و تسطیح زمین نرم | 6d | 2026-07-14 | 2026-07-19 | 102FS-5d | 0d |  | 5,850,000,000 | 4/10/11 | 4/10/11 | 1405/4/23 | 1405/4/28 | 104/10/11 | 104/10/11 | 3,000 | متر مکعب |
| 104 | 1.4.2.5 | خاکبرداری و تسطیح زمین کلنگی و دج | 9d | 2026-07-17 | 2026-07-25 | 103FS-3d | 0d |  | 2,950,000,000 | 4/10/11 | 4/10/11 | 1405/4/26 | 1405/5/3 | 104/10/11 | 104/10/11 | 1,000 | متر مکعب |
| 105 | 1.4.2.6 | پی کنی فونداسیون در هر نوع زمین | 15d | 2026-07-24 | 2026-08-07 | 104FS-2d | 0d |  | 2,212,500,000 | 4/10/11 | 4/10/11 | 1405/5/2 | 1405/5/16 | 104/10/11 | 104/10/11 | 750 | متر مکعب |
| 106 | 1.4.2.7 | اتصال سیم زمین به تجهیزات و چاله ارت | 14d | 2026-09-24 | 2026-10-07 | 107FS+7d | 5d |  | 308,000,000 | 4/10/11 | 4/10/11 | 1405/7/2 | 1405/7/15 | 104/10/11 | 104/10/11 | 70 | عدد |
| 107 | 1.4.2.8 | کوبیدن راد | 6d | 2026-09-11 | 2026-09-16 | 108 | 5d | 0d | 68,600,000 | 4/10/11 | 4/10/11 | 1405/6/20 | 1405/6/25 | 104/10/11 | 104/10/11 | 70 | عدد |
| 108 | 1.4.2.9 | بتن ریزی | 15d | 2026-08-27 | 2026-09-10 | 110, 109 | 0d |  | 3,520,000,000 | 4/10/11 | 4/10/11 | 1405/6/5 | 1405/6/19 | 104/10/11 | 104/10/11 | 400 | متر مکعب |
| 109 | 1.4.2.10 | جداسازی و حمل | 14d | 2026-08-08 | 2026-08-21 | 105 | 5d |  | 3,400,000,000 | 4/10/11 | 4/10/11 | 1405/5/17 | 1405/5/30 | 104/10/11 | 104/10/11 |  | پروژه |
| 110 | 1.4.2.11 | تیر بتنی با تمام تجهیزات جانبی | 19d | 2026-08-08 | 2026-08-26 | 105, 31SS+3d | 0d |  | 2,691,000,000 | 4/10/11 | 4/10/11 | 1405/5/17 | 1405/6/4 | 104/10/11 | 104/10/11 | 390 | عدد |
| 111 | 1.4.2.12 | (OPGW) اجرای سیم گارد | 13d | 2026-09-11 | 2026-09-23 | 108, 39SS+2d | 0d |  | 1,370,000,000 | 4/10/11 | 4/10/11 | 1405/6/20 | 1405/7/1 | 104/10/11 | 104/10/11 | 10 | کیلومتر مسیر خط |
| 112 | 1.4.2.13 | (Hyena) اجرای سیم هادی | 13d | 2026-09-24 | 2026-10-06 | 111, 43SS+5d | 0d |  | 5,900,000,000 | 4/10/11 | 4/10/11 | 1405/7/2 | 1405/7/14 | 104/10/11 | 104/10/11 | 20 | کیلومتر مسیر خط |
| 113 | 1.4.2.14 | Joint box نصب و تست | 8d | 2026-10-05 | 2026-10-12 | 112FS-2d | 0d |  | 294,000,000 | 4/10/11 | 4/10/11 | 1405/7/13 | 1405/7/20 | 104/10/11 | 104/10/11 |  | عدد |
| 114 | 1.4.2.15 | نصب سکو کات اوت و برقگیر | 8d | 2026-10-13 | 2026-10-20 | 113, 106 | 0d |  | 9,800,000 | 4/10/11 | 4/10/11 | 1405/7/21 | 1405/7/28 | 104/10/11 | 104/10/11 |  | عدد |
| 115 | 1.4.2.16 | نصب سکو مخصوص سر کابل هوایی | 8d | 2026-10-21 | 2026-10-28 | 114 | 0d |  | 9,800,000 | 4/10/11 | 4/10/11 | 1405/7/29 | 1405/8/6 | 104/10/11 | 104/10/11 |  | عدد |
| 116 | 1.4.2.17 | نصب و اجرای مهار به صورت کامل | 6d | 2026-10-29 | 2026-11-03 | 115, 35, 54, 55, 56, 57, 58, 59, 60, 61, 62, 63, 64, 65, 66, 67, 68, 69, 70, 71, 72, 73, 74, 75, 76, 77, 78, 79, 80, 81, 82, 83, 84, 85, 86, 87, 88, 53, 94FS-5d | 0d |  | 46,800,000 | 4/10/11 | 4/10/11 | 1405/8/7 | 1405/8/12 | 104/10/11 | 104/10/11 | 12 | عدد |
| 117 | 1.4.2.18 | نصب انواع کات اوت فیوز و تیغه جداکننده در شبکه فشار متوسط | 6d | 2026-11-04 | 2026-11-09 | 116 | 0d |  | 21,000,000 | 4/10/11 | 4/10/11 | 1405/8/13 | 1405/8/18 | 104/10/11 | 104/10/11 |  | عدد |
| 118 | 1.4.2.19 | نصب کات اوت سه فاز قطع هم زمان | 6d | 2026-11-08 | 2026-11-13 | 117FS-2d | 0d |  | 21,000,000 | 4/10/11 | 4/10/11 | 1405/8/17 | 1405/8/22 | 104/10/11 | 104/10/11 |  | سری |
| 119 | 1.4.2.20 | نصب سکسیونر، سکشنالایزر یا ریکلوزر سه فاز | 5d | 2026-11-14 | 2026-11-18 | 118 | 0d |  | 330,000,000 | 4/10/11 | 4/10/11 | 1405/8/23 | 1405/8/27 | 104/10/11 | 104/10/11 |  | عدد |
| 120 | 1.4.2.21 | نصب برقگیر فشار متوسط هوایی | 5d | 2026-11-19 | 2026-11-23 | 119 | 0d |  | 27,000,000 | 4/10/11 | 4/10/11 | 1405/8/28 | 1405/9/2 | 104/10/11 | 104/10/11 |  | عدد |
| 121 | 1.4.2.22 | احداث کانال کابل از تیرهای هوایی تا ساختمان کنترل پست رستاق | 5d | 2026-11-24 | 2026-11-28 | 120 | 0d |  | 3,000,000,000 | 4/10/11 | 4/10/11 | 1405/9/3 | 1405/9/7 | 104/10/11 | 104/10/11 | 50 | متر |
| 122 | 1.4.2.23 | با تجهیزات جانبی در پست رستاق MV نصب تابلوهای | 6d | 2026-11-29 | 2026-12-04 | 121, 47, 51, 89, 90 | 0d |  | 600,000,000 | 4/10/11 | 4/10/11 | 1405/9/8 | 1405/9/13 | 104/10/11 | 104/10/11 |  | دستگاه |
| 123 | 1.4.2.24 | MV& CONT کابل اندازی | 6d | 2026-12-05 | 2026-12-10 | 122 | 0d |  | 540,000,000 | 4/10/11 | 4/10/11 | 1405/9/14 | 1405/9/19 | 104/10/11 | 104/10/11 |  | AS REQ |
| 124 | 1.4.2.25 | اصلاح مدارات و تابلو های کنترل، اندازه گیری | 5d | 2026-12-11 | 2026-12-15 | 123 | 0d |  | 490,000,000 | 4/10/11 | 4/10/11 | 1405/9/20 | 1405/9/24 | 104/10/11 | 104/10/11 |  | AS REQ |
| 125 | 1.4.2.26 | نصب، تست و راه اندازی تجهیزات داخلی پست | 7d | 2026-12-16 | 2026-12-22 | 124, 91, 92, 93 | 0d |  | 490,000,000 | 4/10/11 | 4/10/11 | 1405/9/25 | 1405/10/1 | 104/10/11 | 104/10/11 |  | AS REQ |
| 126 | 1.4.2.27 | خط و پست رستاق (AS BUILT) ارائه نقشه های | 5d | 2026-12-23 | 2026-12-27 | 125 | 0d |  | 490,000,000 | 4/10/11 | 4/10/11 | 1405/10/2 | 1405/10/6 | 104/10/11 | 104/10/11 |  | پروژه |
| 127 | 1.4.2.28 | تحویل موقت | 1d | 2026-12-28 | 2026-12-28 | 126 | 0d |  |  | 4/10/11 | 4/10/11 | 1405/10/7 | 1405/10/7 | 104/10/11 | 104/10/11 |  | پروژه |
